# Projekt příklad

Schedule from MS Project, 2023-11-01 to 2023-12-14, costs in Kč.
Slezska univerzita

## Calendars

- příklad: Mon-Fri 08:00-12:00, 13:00-17:00; Sat-Sun off. Exceptions (off unless hours are given): 2023-11-17 (Den boje za svobodu).

## Resources

| Resource | Unit | Rate |
| --- | --- | --- |
| Eva Benešová |  | 250 |
| Jan Dvořák |  | 250 |
| František Janda |  | 250 |
| Eva Kolínská |  | 250 |
| údržbáři |  | 250 |
| malíři |  | 250 |
| zedníci |  | 250 |
| koberec | m2 | 250 |
| pozvánky | ks | 50 |
| síťový kabel | m. | 80 |
| malba | l | 300 |
| cihly | ks | 50 |
| papír |  |  |
| toner |  |  |
| telefon |  |  |
| počítače |  |  |
| nábytek |  |  |

## Schedule

| ID | WBS | Task | Type | Duration | Start | Finish | Predecessors | Total slack | Free slack | Resources | Work | Cost |
| --- | --- | --- | --- | --- | --- | --- | --- | --- | --- | --- | --- | --- |
| 1 | 1 | **Rekonstrukce zasedací místnosti** |  | 30d | 2023-11-01 | 2023-12-14 |  | 0d |  | telefon [0.1%]; toner [0.1%]; papír [0.1%] | 280h | 659,150 |
| 2 | 1.1 | koncepce vybavení místnosti |  | 1w | 2023-11-01 | 2023-11-08 |  | 0d |  | Eva Benešová | 40h | 10,000 |
| 3 | 1.2 | rozpočet vybavení místnosti |  | 2d | 2023-11-03 | 2023-11-07 | 2SS+2d | 1d |  | Eva Kolínská | 16h | 4,000 |
| 4 | 1.3 | schválení koncepce a rozpočtu vybavení |  | 1d | 2023-11-08 | 2023-11-09 | 2, 3 | 0d |  | František Janda | 8h | 2,000 |
| 5 | 1.4 | výběr a objednání počítačů |  | 6d | 2023-11-09 | 2023-11-20 | 4 | 2d | 0d | Jan Dvořák [50%] | 24h | 6,000 |
| 6 | 1.5 | dodání počítaču a dataprojektoru |  | 1d | 2023-12-01 | 2023-12-04 | 5FS+9d | 2d |  | počítače [0.1%] |  | 200,000 |
| 7 | 1.6 | zazdění dveří |  | 2d | 2023-11-09 | 2023-11-13 | 4 | 8d | 0d | zedníci [200%]; cihly [50 ks] | 32h | 10,500 |
| 8 | 1.7 | podhled |  | 1d | 2023-11-13 | 2023-11-14 | 7 | 8d | 0d | zedníci [200%] | 16h | 4,000 |
| 9 | 1.8 | elektroinstalace |  | 1d | 2023-11-14 | 2023-11-15 | 8 | 8d | 0d | údržbáři; síťový kabel [60 m.] | 8h | 6,800 |
| 10 | 1.9 | vymalování |  | 1d | 2023-11-15 | 2023-11-16 | 9 | 8d | 0d | malíři [200%]; malba [20 l] | 16h | 10,000 |
| 11 | 1.10 | položení koberce |  | 3d | 2023-11-16 | 2023-11-22 | 10 | 8d |  | údržbáři; koberec [100 m2] | 24h | 31,000 |
| 12 | 1.11 | výběr a objednání nábyytku |  | 2d | 2023-11-09 | 2023-11-13 | 4 | 0d |  | Eva Kolínská; Jan Dvořák [50%] | 16h | 4,000 |
| 13 | 1.12 | dodání a montáž nábytku |  | 1d | 2023-12-04 | 2023-12-05 | 11, 12FS+14d | 0d |  | nábytek [0.1%]; údržbáři [300%] | 24h | 356,000 |
| 14 | 1.13 | instalace sítě |  | 1d | 2023-12-05 | 2023-12-06 | 13 | 0d |  | František Janda | 8h | 2,000 |
| 15 | 1.14 | instalace počítačů |  | 1d | 2023-12-06 | 2023-12-07 | 6, 14 | 0d |  | Eva Benešová | 8h | 2,000 |
| 16 | 1.15 | příprava rezervačního software |  | 5d | 2023-12-07 | 2023-12-14 | 15 | 0d |  | Eva Kolínská | 40h | 10,000 |
| 17 | 1.16 | zahájení provozu místnosti | milestone | 0d | 2023-12-14 | 2023-12-14 | 15, 16 | 0d |  | Eva Benešová; Eva Kolínská; František Janda; Jan Dvořák |  |  |
