# Projekt zkouška

Schedule from MS Project, 2023-11-01 to 2023-12-18.

## Calendars

- Zkouška: Mon-Fri 08:00-12:00, 13:00-17:00; Sat-Sun off. Exceptions (off unless hours are given): 2023-11-17 (Den boje za svobodu).

## Schedule

| ID | WBS | Task | Type | Duration | Start | Finish | Predecessors | Total slack | Free slack |
| --- | --- | --- | --- | --- | --- | --- | --- | --- | --- |
| 1 | 1 | **Rekonstrukce zasedací místnosti** |  | 32d | 2023-11-01 | 2023-12-18 |  | 0d |  |
| 2 | 1.1 | koncepce vybavení místnosti |  | 1w | 2023-11-01 | 2023-11-08 |  | 0d |  |
| 3 | 1.2 | rozpočet vybavení místnosti |  | 2d | 2023-11-03 | 2023-11-07 | 2SS+2d | 1d |  |
| 4 | 1.3 | schválení koncepce a rozpočtu vybavení |  | 1d | 2023-11-08 | 2023-11-09 | 2, 3 | 0d |  |
| 5 | 1.4 | výběr a objednání počítačů |  | 6d | 2023-11-09 | 2023-11-20 | 4 | 4d | 0d |
| 6 | 1.5 | dodání počítaču a dataprojektoru |  | 1d | 2023-12-01 | 2023-12-04 | 5FS+9d | 4d |  |
| 7 | 1.6 | zazdění dveří |  | 2d | 2023-11-09 | 2023-11-13 | 4 | 10d | 0d |
| 8 | 1.7 | podhled |  | 1d | 2023-11-13 | 2023-11-14 | 7 | 10d | 0d |
| 9 | 1.8 | elektroinstalace |  | 1d | 2023-11-14 | 2023-11-15 | 8 | 10d | 0d |
| 10 | 1.9 | vymalování |  | 1d | 2023-11-15 | 2023-11-16 | 9 | 10d | 0d |
| 11 | 1.10 | položení koberce |  | 3d | 2023-11-16 | 2023-11-22 | 10 | 10d |  |
| 12 | 1.11 | výběr a objednání nábyytku |  | 4d | 2023-11-09 | 2023-11-15 | 4 | 0d |  |
| 13 | 1.12 | dodání a montáž nábytku |  | 1d | 2023-12-06 | 2023-12-07 | 11, 12FS+14d | 0d |  |
| 14 | 1.13 | instalace sítě |  | 1d | 2023-12-07 | 2023-12-08 | 13 | 0d |  |
| 15 | 1.14 | instalace počítačů |  | 1d | 2023-12-08 | 2023-12-11 | 6, 14 | 0d |  |
| 16 | 1.15 | příprava rezervačního software |  | 5d | 2023-12-11 | 2023-12-18 | 15 | 0d |  |
| 17 | 1.16 | zahájení provozu místnosti | milestone | 0d | 2023-12-18 | 2023-12-18 | 15, 16 | 0d |  |
